# Cronograma

Schedule from MS Project, 2012-06-01 to 2012-12-03.

## Calendars

- Estándar: Mon-Sun 07:00-12:00, 13:00-16:00.

## Resources

| Resource | Group | Rate | Cost per use |
| --- | --- | --- | --- |
| TOPOGRAFO | Mano de Obra | 19.18 |  |
| CAPATAZ | Mano de Obra | 19.18 |  |
| OPERARIO | Mano de Obra | 14.75 |  |
| OFICIAL | Mano de Obra | 12.84 |  |
| PEON | Mano de Obra | 11.58 |  |
| CORTADOR | Mano de Obra | 17.7 |  |
| NIVELADOR | Mano de Obra | 14.75 |  |
| TÉCNICO SOLDADOR | Mano de Obra | 17.7 |  |
| TÉCNICO CALDERERO | Mano de Obra | 19.18 |  |
| TÉCNICO CONTROL DE CALIDAD | Mano de Obra | 14.75 |  |
| LUBRICANTES GRASAS Y FILTROS | Material |  |  |
| ALAMBRE NEGRO RECOCIDO # 16 | Material |  | 3.16 |
| ALAMBRE NEGRO RECOCIDO # 8 | Material |  | 3.16 |
| CLAVOS DIFERENTES MEDIDAS | Material |  | 3.45 |
| PERNO DE ANCLAJE 1 1/2" X 700mm | Material |  | 58.22 |
| PERNO AUTOEXPANSIVOS TIPO CUÑA 3/8" X 5" | Material |  | 5.64 |
| PERNO DE ANCLAJE 5/8" X 0.50 m | Material |  | 9.69 |
| PERNOS 1/4" X 3" | Material |  | 1.82 |
| TUERCAS HEXAGONALES 1 1/2" | Material |  | 5.63 |
| ACERO CORRUGADO fy=4200 kg/cm2 GRADO 60 | Material |  | 2.68 |
| LAMINA REFLECTIVA ALTA INTENSIDAD | Material |  | 10.52 |
| ARENA DE SILICE | Material |  | 34.57 |
| JUNTA ELASTOMERICA ESTRUCTURAL | Material |  | 193.92 |
| ASFALTO RC-250 | Material |  | 10.74 |
| EMULSION ASFALTICA SUPER ESTABLE | Material |  | 9.63 |
| PEGAMENTO PARA NEOPRENO | Material |  | 45.9 |
| CEMENTO PORTLAND TIPO I (42.5 kg) | Material |  | 19.55 |
| CEMENTO GROUTING (30 kg) | Material |  | 76.93 |
| CONCRETO POLIMERICO | Material |  | 75.76 |
| NEOPRENE 0.40 x 0.35 +04 INSERTOS METALICOS | Material |  | 668.59 |
| SOLDADURA AWS E7018 O SIMILAR | Material |  | 13.82 |
| SOLDADURA AWS E6011 | Material |  | 13.82 |
| OXIGENO | Material |  | 6.28 |
| ACETILENO | Material |  | 23.78 |
| ACCESORIOS PARA TUB. HDPE | Material |  |  |
| ACCESORIOS PARA MOTOBOMBA | Material |  |  |
| BARRENO 5' X 1/8" | Material |  | 329.79 |
| LACA DESMOLDANTE | Material |  | 90.51 |
| ADHESIVO EPÓXICO DE FIJACION | Material |  | 106.52 |
| ADITIVO CURADOR | Material |  | 18.24 |
| FIBRA DE VIDRIO DE 4 mm ACABADO | Material |  | 120.22 |
| CINTA DE SEGURIDAD | Material |  | 36.03 |
| CILINDROS METÁLICOS EN BUEN ESTADO Y CON TAPA (55Gal) | Material |  | 60 |
| PLANTAS NATIVAS | Material |  | 9.55 |
| ESPUMA SINTETICA DE POLIERAETANO (TEKNOPORT) e=2" | Material |  | 6.62 |
| MADERA TORNILLO | Material |  | 4.55 |
| TIRAS DE MADERA TORNILLO SEMICIRCULAR D=2 cm | Material |  | 1.32 |
| ESTACA DE MADERA | Material |  | 3.32 |
| TRIPLAY DE 19 mm | Material |  | 95.35 |
| GAVION CAJA FUERTE DE 5 m x 1 m x1m ( Malla 10 x12 cm ;2.7 mm) REVESTIDO CON PVC | Material |  | 328.09 |
| GAVION TIPO COLCHON 5 m x 2 m x 0.50m ( Malla 10 x12 cm ;2.7 mm) REVESTIDO CON PVC | Material |  | 396.91 |
| GAVION CAJA FUERTE DE 5 m x 1 m x1.5m ( Malla 10 x12 cm ;2.7 mm) REVESTIDO CON PVC | Material |  | 435.36 |
| APOYOS PROVISIONALES | Material |  | 6000 |
| ACERO ESTRUCTURAL ASTM A 709 GRADO 50 | Material |  | 3299.09 |
| ANGULO DE ACERO 1" X 1" X 3/16" | Material |  | 6.2 |
| PLATINA DE ACERO 2" X 1/8" | Material |  | 4.52 |
| PLATINA DE ACERO 3/8" X 0.125 X 2.20 m | Material |  | 222.79 |
| PLATINA DE ACERO 3/8" (B3) | Material |  | 222.79 |
| COMBUSTIBLE | Material |  | 10.35 |
| DISOLVENTE XILOL | Material |  | 31.9 |
| DISOLVENTE PARA PINTURA ESMALTE POLIURETANO | Material |  | 56.49 |
| DISOLVENTE PARA PINTURA IMPRIMANTE | Material |  | 41.52 |
| DISOLVENTE PARA PINTURA EPOXICO | Material |  | 42.37 |
| PINTURA ANTICORROSIVA | Material |  | 25.61 |
| PINTURA DE RESINA EPOXICA | Material |  | 84.2 |
| PINTURA DE POLIURETANO ALIFATICA AMERSHIEL O SIMILAR | Material |  | 134.96 |
| TINTA SERIGRAFICA NEGRA O ROJA | Material |  | 1109.11 |
| PINTURA IMPRIMANTE A BASE DE ZINC INORGANICO | Material |  | 176.5 |
| IMPRIMANTE DE ADHESIVO EPOXICO | Material |  | 174.64 |
| PINTURA ESMALTE SINTETICO | Material |  | 28.22 |
| PINTURA PARA TRAFICO TTP-115F COLOR AMARILLO | Material |  | 42.28 |
| ARANDELA METÁLICA DE 3" | Material |  | 4.13 |
| PLANCHA DE ACERO PL.38 0.65mX0.45m | Material |  | 336.82 |
| PLANCHA DE ACERO 5/8" x 0.20 x 0.17 m. | Material |  | 14.35 |
| PLANCHA METALICA ASTM A36 e=1/4" 0.125 m x 0.125 m. | Material |  | 2.36 |
| TUBERIA METALICA CORRUGADA TIPO ARMCO D=36" | Material |  | 340.46 |
| TUBERIA METALICA CORRUGADA TIPO ARMCO D=24" | Material |  | 224.52 |
| PLANCHA DE TECKNOPOR DE 1" X 4' X 8' | Material |  | 10.15 |
| TUBO DE FIERRO 3" SCH-40 | Material |  | 39.05 |
| TUBO DE FIERRO 2" SCH-40 | Material |  | 21.55 |
| TUBO DE FIERRO GALVANIZADO D= 2" esp=2.5mm | Material |  | 20.73 |
| CABLES ESTROBOS ETC | Material |  | 30 |
| TUBO PVC SAP D=4" | Material |  | 16.35 |
| TUBO PVC SAP D=2" | Material |  | 4.56 |
| TUBO SIN PERFORAR HDPE D=4" | Material |  | 7.28 |
| TUBO HDPE PERFORADO D=4" | Material |  | 7.28 |
| CODO PVC SAP 4"X45º | Material |  | 24.73 |
| GEOTEXTIL NO TEJIDO CLASE 2 | Material |  | 2.59 |
| TUBO PVC SAP D= 6" CLASE 5 | Material |  | 27.4 |
| MICROESFERAS DE VIDRIO | Material |  | 3.47 |
| HERRAMIENTAS MANUALES | Equipo | 8 |  |
| MOTOSIERRA | Equipo | 6.78 |  |
| MEZCLADORA DE CONCRETO DE 11p3 18 HP | Equipo | 9.56 |  |
| CAMION CISTERNA 4 X 2 (AGUA) 122 HP 2 000 gl | Equipo | 128.96 |  |
| CAMION VOLQUETE 15 m3 | Equipo | 258.04 |  |
| MONTACARGA 80 HP 5 000 kg | Equipo | 85.75 |  |
| SOLDADORA ELECTRICA TRIFASICA 400 A | Equipo | 10.77 |  |
| MOTOBOMBA 34 HP 8" | Equipo | 63.79 |  |
| MAQUINARIA PARA PINTAR MARCAS EN PAVIMENTOS | Equipo | 36.03 |  |
| EQUIPO DE OXICORTE | Equipo | 13.2 |  |
| TIRFOR DE 5 ton | Equipo | 16.2 |  |
| GATAS DE 50 ton | Equipo | 16.2 |  |
| EQUIPO DE ARENADO | Equipo | 38.69 |  |
| EQUIPO DE PINTURA AIRLESS | Equipo | 28.63 |  |
| TECLE DE 5 ton | Equipo | 13.5 |  |
| COMPRESORA NEUMATICA 87 HP 250-330 PCM | Equipo | 77.01 |  |
| COMPACTADOR VIBRATORIO TIPO PLANCHA 7 HP | Equipo | 26.12 |  |
| RODILLO LISO VIBRATORIO AUTOPROPULSADO 101-135HP 10-12 ton | Equipo | 149.4 |  |
| RODILLO LISO VIBRATORIO MANUAL 10.8HP 0.8-1.1 ton | Equipo | 26.12 |  |
| TRACTOR DE ORUGAS DE 140 -160 HP | Equipo | 243.06 |  |
| CARGADOR SOBRE LLANTAS 125-155 HP 3 yd3 | Equipo | 170.08 |  |
| MARTILLO NEUMATICO DE 29 kg | Equipo | 3.89 |  |
| RETROEXCAVADORA SOBRE ORUGAS 115-165 HP -1.4 yd3 (1.10 m3) | Equipo | 214.42 |  |
| LAVADORA GUSANO EJE SIMPLE D=48" | Equipo | 56.55 |  |
| VIBRADOR DE CONCRETO 4 HP 2.40" | Equipo | 5.38 |  |
| MOTOSOLDADORA DE 225 A | Equipo | 19.52 |  |
| MOTONIVELADORA DE 145-150 HP | Equipo | 187.97 |  |
| ZARANDA ESTATICA | Equipo | 4 |  |
| GRUPO ELECTROGENO 140 HP 90 KW | Equipo | 154.57 |  |
| GRUPO ELECTROGENO 230 HP 150 KW | Equipo | 172.83 |  |
| FAJA TRANSPORTADORA 18" X 4' MOTOR ELECTRICO 3 KW 150 ton/h | Equipo | 5.64 |  |
| GRUA HIDRAULICA AUTOPROPULSADA 127 HP 18 ton 9 m | Equipo | 189 |  |
| ESTACION TOTAL | Equipo | 15.15 |  |
| NIVEL TOPOGRAFICO | Equipo | 3.37 |  |
| MANTENIMIENTO DE TRANSITO Y SEGURIDAD VIAL | Subcontrato |  | 5379.89 |
| MOVILIZACION Y DESMOVILIZACION DE EQUIPO Y HERRAMIENTAS | Subcontrato |  | 28054.7 |
| TRANSPORTE DE ESTRUCTURA A OBRA (CHIMBOTE-OBRA). INCLUYE SEGURO | Subcontrato |  | 1258 |
| PRUEBAS DE SOLDADURA (TINTES PENETRANTES Y RADIOGRAFICAS) | Subcontrato |  | 120 |
| MONITOREO DE LA CALIDAD DEL AGUA (VER DETALLE EN CUADRO 12.2.3. a) | Subcontrato |  | 1630.8 |
| MONITOREO DE LA CALIDAD DEL AIRE (VER DETALLE EN CUADRO 12.2.3. b) | Subcontrato |  | 3591 |
| MONITOREO DEL RUIDO (VER DETALLE EN CUADRO 12.2.3. c) | Subcontrato |  | 756 |
| EQUIPO DE PRIMEROS AUXILIOS (VER DETALLE EN CUADRO 12.2.4 a) | Subcontrato |  | 2340 |
| IMPLEMENTOS DE SEGURIDAD (VER DETALLE EN CUADRO 12.2.4 b) | Subcontrato |  | 32644 |
| EQUIPOS CONTRA INCENDIOS (VER DETALLE EN CUADRO 12.2.4 c) | Subcontrato |  | 2850 |
| EQUIPOS CONTRA DERRAMES DE SUSTANCIAS TÓXICAS (VER DETALLE EN CUADRO 12.2.4 d) | Subcontrato |  | 4210 |
| MECANISMOS DE COMUNICACIÓN E INFORMACIÓN ENTRE POBLADORES Y EMPRES | Subcontrato |  | 2000 |
| ELIMINACIÓN DE LUBRICANTES GRASAS COMBUSTIBLES Y OTROS | Subcontrato |  | 9396 |
| UTILES DE ESCRITORIO (VER DETALLE EN CUADRO 12.2.1) | Subcontrato |  | 1350 |
| SEÑALES AMBIENTALES TEMPORALES | Subcontrato |  | 180 |

## Schedule

| ID | WBS | Task | Duration | Start | Finish | Predecessors | Total slack | Free slack | Resources | Work | Cost | Text1 | Text8 | Text3 | Text4 | Text2 | Text6 |
| --- | --- | --- | --- | --- | --- | --- | --- | --- | --- | --- | --- | --- | --- | --- | --- | --- | --- |
| 1 | 1 | **PUENTE MALCAS** | 180d | 2012-06-01 | 2012-11-28 |  | 5d |  |  | 32588.6h | 1,755,148.47 | 01 | 000000000000001 |  |  |  |  |
| 2 | 1.1 | **OBRAS PRELIMINARES** | 178d | 2012-06-01 | 2012-11-26 |  | 5d |  |  | 3886.22h | 112,073.49 | 01.01 | 000000000000002 |  |  |  |  |
| 3 | 1.1.1 | MOVILIZACION Y DESMOVILIZACION DE EQUIPO Y HERRAMIENTAS | 12d | 2012-06-01 | 2012-11-26 |  | 5d | 0d | MOVILIZACION Y DESMOVILIZACION DE EQUIPO Y HERRAMIENTAS [8.3%] | 8h | 28,054.66 | 01.01.01 | 000000000000003 | 28054.66 | 28054.66 |  |  |
| 4 | 1.1.2 | TRAZO, REPLANTEO Y CONTROL | 176d | 2012-06-02 | 2012-11-25 | 3SS+1d | 8d | 0d | PINTURA ESMALTE SINTETICO [32941.7%]; TOPOGRAFO; PEON [399.3%]; NIVELADOR; ESTACION TOTAL; NIVEL TOPOGRAFICO; CLAVOS DIFERENTES MEDIDAS [54902.8%]; MADERA TORNILLO [126276%] | 3513.78h | 62,040.16 | 01.01.02 | 000000000000004 | 2.26 | 62040.16 | 27451.4 | 500 |
| 5 | 1.1.3 | DEMOLICION DE ESTRUCTURAS DE CONCRETO EXISTENTES | 1d | 2012-06-03 | 2012-06-04 | 6 | 173d | 0d | CAPATAZ [5.9%]; OPERARIO [118.7%]; PEON [237.5%]; COMPRESORA NEUMATICA 87 HP 250-330 PCM [59.4%]; MARTILLO NEUMATICO DE 29 kg [118.7%]; BARRENO 5' X 1/8" [14.2%] | 86.45h | 1,628.06 | 01.01.03 | 000000000000005 | 114.25 | 1628.06 | 14.25 | 12 |
| 6 | 1.1.4 | CONSTRUCCION DE PASE PROVISIONAL DE VEHICULOS | 1d | 2012-06-02 | 2012-06-03 | 3SS+1d | 6d | 0d | CAPATAZ [167.5%]; OFICIAL [305.4%]; PEON [2126.7%]; CAMION CISTERNA 4 X 2 (AGUA) 122 HP 2 000 gl [54.5%]; CAMION VOLQUETE 15 m3 [224.6%]; RODILLO LISO VIBRATORIO AUTOPROPULSADO 101-135HP 10-12 ton [75.6%]; TRACTOR DE ORUGAS DE 140 -160 HP [38.2%]; CARGADOR SOBRE LLANTAS 125-155 HP 3 yd3 [194.9%]; RETROEXCAVADORA SOBRE ORUGAS 115-165 HP -1.4 yd3 (1.10 m3) [73%]; MOTONIVELADORA DE 145-150 HP [75.6%]; ZARANDA ESTATICA [139%]; TUBERIA METALICA CORRUGADA TIPO ARMCO D=24" [2556.2%] | 277.99h | 20,350.61 | 01.01.04 | 000000000000006 | 14.33 | 20350.61 | 1420.14 |  |
| 7 | 1.1.5 | **DEMOLICIONES** | 10d | 2012-06-18 | 2012-06-28 |  | 0d |  |  |  |  |  |  |  |  |  |  |
| 8 | 1.1.5.1 | DEMOLICION DE CONCRETO CICLOPEO | 10d | 2012-06-18 | 2012-06-28 | 14 | 0d |  |  |  |  |  |  |  |  |  |  |
| 9 | 1.1.5.2 | DEMOLICION DE CONCRETO ARMADO f'c=210 Kg/cm2 | 5d | 2012-06-18 | 2012-06-23 | 8SS | 163d |  |  |  |  |  |  |  |  |  |  |
| 10 | 1.1.5.3 | TRANSPORTE DE MATERIAL EXCEDENTE D<= 1KM | 10d | 2012-06-18 | 2012-06-28 | 8SS | 158d |  |  |  |  |  |  |  |  |  |  |
| 11 | 1.1.6 | **DESMONTAJE DE ESTRUCTURAS** | 14d | 2012-06-01 | 2012-06-15 |  | 5d |  |  |  |  |  |  |  |  |  |  |
| 12 | 1.1.6.1 | TRASLADO DE NARIZ DE LANZAMIENTO LIMA - PUENTE MALCAS | 2d | 2012-06-01 | 2012-06-03 | 3SS | 5d | 2d |  |  |  |  |  |  |  |  |  |
| 13 | 1.1.6.2 | ARMADO DE NARIZ DE LANZAMIENTO | 5d | 2012-06-05 | 2012-06-10 | 12 | 3d |  |  |  |  |  |  |  |  |  |  |
| 14 | 1.1.6.3 | DESMONTAJE DE ESTRUCTURA Y NARIZ | 5d | 2012-06-13 | 2012-06-18 | 13 | 0d |  |  |  |  |  |  |  |  |  |  |
| 15 | 1.1.6.4 | TRASLADO DE ESTRUCTURA Y NARIZ (OBRA - LIMA) | 2d | 2012-06-13 | 2012-06-15 | 14 | 170d |  |  |  |  |  |  |  |  |  |  |
| 16 | 1.2 | **OBRAS COMPLEMENTARIAS** | 1d | 2012-06-04 | 2012-06-05 |  | 180d |  |  | 2.71h | 211.94 | 01.02 | 000000000000007 |  |  |  |  |
| 17 | 1.2.1 | ENCAUSAMIENTO DE CANALES DE REGADIO ALEDAÑOS | 1d | 2012-06-04 | 2012-06-05 | 5 | 180d |  | CAPATAZ [1.1%]; OFICIAL [10.9%]; PEON [10.9%]; RETROEXCAVADORA SOBRE ORUGAS 115-165 HP -1.4 yd3 (1.10 m3) [10.9%] | 2.71h | 211.94 | 01.02.01 | 000000000000008 | 1.99 | 211.94 | 106.5 | 980 |
| 18 | 1.3 | **MANTENIMIENTO Y SEÑALIZACION EN ZONA DE TRABAJO** | 178d | 2012-06-02 | 2012-11-27 |  | 6d |  |  | 288h | 32,279.34 | 01.03 | 000000000000009 |  |  |  |  |
| 19 | 1.3.1 | MANTENIMIENTO DE TRANSITO Y SEGURIDAD VIAL | 178d | 2012-06-02 | 2012-11-27 | 6SS | 6d |  | MANTENIMIENTO DE TRANSITO Y SEGURIDAD VIAL [600%] | 288h | 32,279.34 | 01.03.01 | 000000000000010 | 5379.89 | 32279.34 |  |  |
| 20 | 1.4 | **ESTRIBOS** | 45d | 2012-06-23 | 2012-08-07 |  | 0d |  |  | 5376.22h | 210,606.34 | 01.04 | 000000000000011 |  |  |  |  |
| 21 | 1.4.1 | EXCAVACION DE MATERIAL SUELTO | 1d | 2012-06-23 | 2012-06-24 | 8SS+5d | 0d |  | CAPATAZ [8.9%]; OFICIAL [88.4%]; PEON [352.9%]; RETROEXCAVADORA SOBRE ORUGAS 115-165 HP -1.4 yd3 (1.10 m3) [88.4%] | 86.19h | 3,935.58 | 01.04.01.01 | 000000000000013 | 6.37 | 3935.58 | 617.83 | 350 |
| 22 | 1.4.2 | ENCOFRADO Y DESENCOFRADO DE ESTRIBOS Y MUROS DE CONTENCIÓN | 30d | 2012-07-08 | 2012-08-07 | 23SS+5d | 0d |  | LACA DESMOLDANTE [2944.8%]; CAPATAZ [9.8%]; OPERARIO [97.8%]; OFICIAL [97.8%]; PEON [195.7%]; ALAMBRE NEGRO RECOCIDO # 8 [11779%]; CLAVOS DIFERENTES MEDIDAS [11779%]; MADERA TORNILLO [90698.3%]; TRIPLAY DE 19 mm [7067.4%] | 1379.79h | 32,928.19 | 01.04.02.01 | 000000000000015 | 55.91 | 32928.19 | 588.95 | 14 |
| 23 | 1.4.3 | ACERO DE REFUERZO fy=4200 kg/cm2 | 24d | 2012-07-03 | 2012-07-27 | 21SS+10d | 0d |  | CAPATAZ [9.9%]; OPERARIO [99%]; OFICIAL [99%]; PEON [99%]; ALAMBRE NEGRO RECOCIDO # 16 [116361%]; ACERO CORRUGADO fy=4200 kg/cm2 GRADO 60 | 2308.6h | 101,233.81 | 01.04.03.01 | 000000000000017 | 4.35 | 101233.81 | 23272.14 | 250 |
| 24 | 1.4.4 | CONCRETO CLASE H ( f'c = 100 kg/cm2 ) | 1d | 2012-07-03 | 2012-07-04 | 22SS-5d | 0d |  | CEMENTO PORTLAND TIPO I (42.5 kg) [1296%]; ADITIVO CURADOR [54.7%]; COMBUSTIBLE [80.6%]; CAPATAZ [8.6%]; OPERARIO [48%]; OFICIAL [49%]; PEON [102.3%]; MEZCLADORA DE CONCRETO DE 11p3 18 HP [16%]; CAMION CISTERNA 4 X 2 (AGUA) 122 HP 2 000 gl [0.6%]; CAMION VOLQUETE 15 m3 [3.3%]; CARGADOR SOBRE LLANTAS 125-155 HP 3 yd3 [1.6%]; RETROEXCAVADORA SOBRE ORUGAS 115-165 HP -1.4 yd3 (1.10 m3) [0.6%]; VIBRADOR DE CONCRETO 4 HP 2.40" [16%]; ZARANDA ESTATICA [1.1%] | 19.77h | 2,388.17 | 01.06.03.01 | 000000000000034 | 216.32 | 623 | 2.88 | 18 |
| 25 | 1.4.5 | CONCRETO CLASE D (f'c=210 kg/cm2) | 21d | 2012-07-11 | 2012-08-01 | 24FS+7d | 0d |  | CEMENTO PORTLAND TIPO I (42.5 kg) [207396%]; ADITIVO CURADOR [4378.4%]; COMBUSTIBLE [6452.3%]; CAPATAZ [53.1%]; OPERARIO [295.4%]; OFICIAL [301.5%]; PEON [629.9%]; MEZCLADORA DE CONCRETO DE 11p3 18 HP [98.5%]; CAMION CISTERNA 4 X 2 (AGUA) 122 HP 2 000 gl [3.8%]; CAMION VOLQUETE 15 m3 [20.1%]; CARGADOR SOBRE LLANTAS 125-155 HP 3 yd3 [9.5%]; RETROEXCAVADORA SOBRE ORUGAS 115-165 HP -1.4 yd3 (1.10 m3) [3.6%]; VIBRADOR DE CONCRETO 4 HP 2.40" [98.5%]; ZARANDA ESTATICA [7%] | 1581.87h | 70,120.59 | 01.04.04.02 | 000000000000020 | 304.29 | 70120.59 | 230.44 | 18 |

| ID | WBS | Task | Duration | Start | Finish | Predecessors | Total slack | Free slack | Resources | Work | Cost | Text1 | Text8 | Text2 | Text3 | Text4 | Text6 |
| --- | --- | --- | --- | --- | --- | --- | --- | --- | --- | --- | --- | --- | --- | --- | --- | --- | --- |
| 26 | 1.5 | **SUPERESTRUCTURA** | 29d | 2012-10-16 | 2012-11-14 |  | 0d |  |  | 2696.5h | 103,787.1 | 01.05 | 000000000000021 |  |  |  |  |
| 27 | 1.5.1 | ENCOFRADO Y DESENCOFRADO CARAVISTA EN LOSAS Y VEREDA | 24d | 2012-10-21 | 2012-11-14 | 37FS-5d | 0d |  | LACA DESMOLDANTE [1862.1%]; CAPATAZ [9.7%]; OPERARIO [97%]; OFICIAL [97%]; PEON [194%]; ALAMBRE NEGRO RECOCIDO # 8 [7448.4%]; CLAVOS DIFERENTES MEDIDAS [7448.4%]; MADERA TORNILLO [133699%]; TRIPLAY DE 19 mm [4469%] | 1017.97h | 26,251.89 | 01.05.01.01 | 000000000000023 | 372.42 | 70.49 | 26251.89 | 12 |
| 28 | 1.5.2 | ACERO DE REFUERZO fy=4200 kg/cm2 | 21d | 2012-10-16 | 2012-11-06 | 27SS-5d | 0d |  | CAPATAZ [9.8%]; OPERARIO [98.2%]; OFICIAL [98.2%]; PEON [98.2%]; ALAMBRE NEGRO RECOCIDO # 16 [52778.2%]; ACERO CORRUGADO fy=4200 kg/cm2 GRADO 60 | 1047.12h | 45,917.08 | 01.05.02.01 | 000000000000025 | 10555.65 | 4.35 | 45917.08 | 250 |
| 29 | 1.5.3 | CONCRETO CLASE C (f'c=280 kg/cm2) | 5d | 2012-11-06 | 2012-11-11 | 28 | 0d |  | CEMENTO PORTLAND TIPO I (42.5 kg) [101178%]; ADITIVO CURADOR [1931.6%]; COMBUSTIBLE [2575.4%]; CAPATAZ [45.9%]; OPERARIO [255.5%]; OFICIAL [260.8%]; PEON [544.8%]; MEZCLADORA DE CONCRETO DE 11p3 18 HP [85.2%]; CAMION CISTERNA 4 X 2 (AGUA) 122 HP 2 000 gl [3.3%]; CAMION VOLQUETE 15 m3 [17.4%]; CARGADOR SOBRE LLANTAS 125-155 HP 3 yd3 [8.2%]; RETROEXCAVADORA SOBRE ORUGAS 115-165 HP -1.4 yd3 (1.10 m3) [3.1%]; VIBRADOR DE CONCRETO 4 HP 2.40" [85.2%]; ZARANDA ESTATICA [6.1%] | 631.4h | 31,618.13 | 01.05.03.01 | 000000000000027 | 91.98 | 343.75 | 31618.13 | 18 |
| 30 | 1.6 | **LOSAS DE APROXIMACION** | 7d | 2012-11-09 | 2012-11-16 |  | 17d |  |  | 335.68h | 13,597.04 | 01.06 | 000000000000028 |  |  |  |  |
| 31 | 1.6.1 | ENCOFRADO Y DESENCOFRADO CARAVISTA EN LOSAS Y VEREDA | 5d | 2012-11-11 | 2012-11-16 | 29 | 17d | 0d | LACA DESMOLDANTE [94%]; CAPATAZ [7.8%]; OPERARIO [78.3%]; OFICIAL [78.3%]; PEON [156.7%]; ALAMBRE NEGRO RECOCIDO # 8 [376%]; CLAVOS DIFERENTES MEDIDAS [376%]; MADERA TORNILLO [6749.2%]; TRIPLAY DE 19 mm [225.6%] | 51.39h | 1,325.21 | 01.06.01.01 | 000000000000030 | 18.8 | 70.49 | 1325.21 | 12 |
| 32 | 1.6.2 | ACERO DE REFUERZO fy=4200 kg/cm2 | 6d | 2012-11-09 | 2012-11-15 | 31SS-2d | 18d | 0d | CAPATAZ [9.3%]; OPERARIO [92.7%]; OFICIAL [92.7%]; PEON [92.7%]; ALAMBRE NEGRO RECOCIDO # 16 [8108.1%]; ACERO CORRUGADO fy=4200 kg/cm2 GRADO 60 [170270%] | 160.86h | 7,054.05 | 01.06.02.01 | 000000000000032 | 1621.62 | 4.35 | 7054.05 | 250 |
| 33 | 1.6.3 | CONCRETO CLASE H ( f'c = 100 kg/cm2 ) | 1d | 2012-11-09 | 2012-11-10 | 32SS | 22d |  | CEMENTO PORTLAND TIPO I (42.5 kg) [1296%]; ADITIVO CURADOR [54.7%]; COMBUSTIBLE [80.6%]; CAPATAZ [8.6%]; OPERARIO [48%]; OFICIAL [49%]; PEON [102.3%]; MEZCLADORA DE CONCRETO DE 11p3 18 HP [16%]; CAMION CISTERNA 4 X 2 (AGUA) 122 HP 2 000 gl [0.6%]; CAMION VOLQUETE 15 m3 [3.3%]; CARGADOR SOBRE LLANTAS 125-155 HP 3 yd3 [1.6%]; RETROEXCAVADORA SOBRE ORUGAS 115-165 HP -1.4 yd3 (1.10 m3) [0.6%]; VIBRADOR DE CONCRETO 4 HP 2.40" [16%]; ZARANDA ESTATICA [1.1%] | 19.77h | 623 | 01.06.03.01 | 000000000000034 | 2.88 | 216.32 | 623 | 18 |
| 34 | 1.6.4 | CONCRETO CLASE D (f'c=210 kg/cm2) | 1d | 2012-11-11 | 2012-11-12 | 31SS | 21d |  | CEMENTO PORTLAND TIPO I (42.5 kg) [13590%]; ADITIVO CURADOR [286.9%]; COMBUSTIBLE [422.8%]; CAPATAZ [45.2%]; OPERARIO [251.7%]; OFICIAL [256.9%]; PEON [536.6%]; MEZCLADORA DE CONCRETO DE 11p3 18 HP [83.9%]; CAMION CISTERNA 4 X 2 (AGUA) 122 HP 2 000 gl [3.3%]; CAMION VOLQUETE 15 m3 [17.2%]; CARGADOR SOBRE LLANTAS 125-155 HP 3 yd3 [8.1%]; RETROEXCAVADORA SOBRE ORUGAS 115-165 HP -1.4 yd3 (1.10 m3) [3%]; VIBRADOR DE CONCRETO 4 HP 2.40" [83.9%]; ZARANDA ESTATICA [6%] | 103.65h | 4,594.78 | 01.06.03.02 | 000000000000035 | 15.1 | 304.29 | 4594.78 | 18 |
| 35 | 1.7 | **ESTRUCTURA METALICA** | 136d | 2012-07-15 | 2012-11-28 |  | 0d |  |  | 20003.3h | 1,282,593.22 | 01.07 | 000000000000036 |  |  |  |  |
| 36 | 1.7.1 | FABRICACION DE ESTRUCTURA METALICA | 50d | 2012-07-15 | 2012-09-03 | 25SS+4d | 0d |  | COMBUSTIBLE [25435.6%]; PRUEBAS DE SOLDADURA (TINTES PENETRANTES Y RADIOGRAFICAS) [10014%]; OFICIAL [196.4%]; PEON [981.8%]; CORTADOR [196.4%]; TÉCNICO SOLDADOR [196.4%]; TÉCNICO CALDERERO [98.2%]; TÉCNICO CONTROL DE CALIDAD [98.2%]; MONTACARGA 80 HP 5 000 kg [98.2%]; EQUIPO DE OXICORTE [196.4%]; GATAS DE 50 ton [196.4%]; TECLE DE 5 ton [196.4%]; MOTOSOLDADORA DE 225 A [196.4%]; SOLDADURA AWS E7018 O SIMILAR; OXIGENO [120168%]; ACETILENO [40056%]; MADERA TORNILLO [30042%]; ACERO ESTRUCTURAL ASTM A 709 GRADO 50 [10514.7%] | 10815.1h | 733,956.1 | 01.07.01 | 000000000000037 | 100.14 | 7329.3 | 733956.1 |  |
| 37 | 1.7.2 | MONTAJE DE ESTRUCTURA METÁLICA | 33d | 2012-09-23 | 2012-10-26 | 38FS+7d | 0d |  | CABLES ESTROBOS ETC [10014%]; CAPATAZ [98.2%]; OPERARIO [392.7%]; PEON [981.8%]; TÉCNICO SOLDADOR [73.6%]; TÉCNICO CONTROL DE CALIDAD [36.8%]; TIRFOR DE 5 ton [196.4%]; GATAS DE 50 ton [196.4%]; TECLE DE 5 ton [196.4%]; MOTOSOLDADORA DE 225 A [24.5%]; GRUA HIDRAULICA AUTOPROPULSADA 127 HP 18 ton 9 m [196.4%]; SOLDADURA AWS E7018 O SIMILAR [50070%]; MADERA TORNILLO [28499.8%]; APOYOS PROVISIONALES [851.2%] | 6509.1h | 245,871.74 | 01.07.02 | 000000000000038 | 100.14 | 2455.28 | 245871.74 |  |
| 38 | 1.7.3 | ARENADO Y PINTURA ANTICORROSIVA PARA ESTRUCTURA METALICA | 13d | 2012-09-03 | 2012-09-16 | 25, 36 | 0d |  | DISOLVENTE PARA PINTURA IMPRIMANTE [2236.7%]; PINTURA IMPRIMANTE A BASE DE ZINC INORGANICO [12854.5%]; CAPATAZ [19.8%]; OPERARIO [98.9%]; OFICIAL [98.9%]; PEON [98.9%]; EQUIPO DE ARENADO [98.9%]; EQUIPO DE PINTURA AIRLESS [98.9%]; COMPRESORA NEUMATICA 87 HP 250-330 PCM [98.9%]; ARENA DE SILICE [6427.2%] | 637.58h | 45,337.82 | 01.07.03 | 000000000000039 | 1285.45 | 35.27 | 45337.82 | 100 |
| 39 | 1.7.4 | PINTURA ESMALTE EPOXICO PARA ESTRUCTURA METALICA | 13d | 2012-11-02 | 2012-11-15 | 37, 29FS-9d | 0d |  | DISOLVENTE PARA PINTURA EPOXICO [4563.4%]; PINTURA DE RESINA EPOXICA [15219.7%]; CAPATAZ [19.8%]; OPERARIO [98.9%]; OFICIAL [98.9%]; PEON [98.9%]; EQUIPO DE PINTURA AIRLESS [98.9%]; COMPRESORA NEUMATICA 87 HP 250-330 PCM [98.9%] | 534.75h | 30,259.49 | 01.07.04 | 000000000000040 | 1285.45 | 23.54 | 30259.49 | 100 |
| 40 | 1.7.5 | PINTURA DE ACABADO PARA ESTRUCTURA METALICA (POLIURETANO) | 13d | 2012-11-15 | 2012-11-28 | 39 | 0d |  | DISOLVENTE PARA PINTURA ESMALTE POLIURETANO [4563.4%]; PINTURA DE POLIURETANO ALIFATICA AMERSHIEL O SIMILAR [7969.8%]; CAPATAZ [19.8%]; OPERARIO [98.9%]; OFICIAL [98.9%]; PEON [98.9%]; EQUIPO DE PINTURA AIRLESS [98.9%]; COMPRESORA NEUMATICA 87 HP 250-330 PCM [98.9%] | 534.75h | 28,858.35 | 01.07.05 | 000000000000041 | 1285.45 | 22.45 | 28858.35 | 100 |
| 41 | 1.7.6 | TRANSPORTE DE ESTRUCTURA METALICA A OBRA | 25d | 2012-09-03 | 2012-09-28 | 36 | 66d |  | TRANSPORTE DE ESTRUCTURA A OBRA (CHIMBOTE-OBRA). INCLUYE SEGURO [10014%]; GRUA HIDRAULICA AUTOPROPULSADA 127 HP 18 ton 9 m [1%] | 8.01h | 127,490.24 | 01.07.06 | 000000000000042 | 100.14 | 1273.12 | 127490.24 |  |
| 42 | 1.7.7 | **DETALLES EN TABLERO** | 94d | 2012-08-15 | 2012-11-17 |  | 16d |  |  | 964.02h | 70,819.48 | 01.07.07 | 000000000000043 |  |  |  |  |
| 43 | 1.7.7.1 | APARATO APOYO DE NEOPRENO | 2d | 2012-09-23 | 2012-09-25 | 37SS | 68d |  | CEMENTO GROUTING (30 kg) [1496%]; LACA DESMOLDANTE [4.4%]; ADITIVO CURADOR [5.2%]; CAPATAZ [0.4%]; OPERARIO [83.8%]; OFICIAL [83.1%]; PEON [87%]; MEZCLADORA DE CONCRETO DE 11p3 18 HP [0.7%]; CAMION CISTERNA 4 X 2 (AGUA) 122 HP 2 000 gl [0%]; ALAMBRE NEGRO RECOCIDO # 8 [17.6%]; CLAVOS DIFERENTES MEDIDAS [17.6%]; MADERA TORNILLO [135.5%]; TRIPLAY DE 19 mm [10.6%]; PERNO DE ANCLAJE 1 1/2" X 700mm [1600%]; TUERCAS HEXAGONALES 1 1/2" [1600%]; NEOPRENE 0.40 x 0.35 +04 INSERTOS METALICOS [800%]; PLANCHA DE ACERO PL.38 0.65mX0.45m [1600%]; ARANDELA METÁLICA DE 3" [1600%] | 40.81h | 13,557.84 | 01.07.07.01 | 000000000000044 |  | 1694.73 | 13557.84 |  |
| 44 | 1.7.7.2 | ACABADO DE VEREDAS INC. BRUÑAS | 5d | 2012-10-24 | 2012-10-29 | 73SS, 88 | 35d |  | CEMENTO PORTLAND TIPO I (42.5 kg) [864%]; CAPATAZ [9.2%]; OPERARIO [92.2%]; OFICIAL [0.1%]; PEON [92.5%]; CAMION CISTERNA 4 X 2 (AGUA) 122 HP 2 000 gl [0.1%]; CAMION VOLQUETE 15 m3 [0.2%]; CARGADOR SOBRE LLANTAS 125-155 HP 3 yd3 [0.1%]; RETROEXCAVADORA SOBRE ORUGAS 115-165 HP -1.4 yd3 (1.10 m3) [0%]; ZARANDA ESTATICA [0.1%] | 77.79h | 1,300.84 | 01.07.07.02 | 000000000000045 | 69.12 | 18.82 | 1300.84 | 15 |
| 45 | 1.7.7.3 | TUBO PVC D=6" EN VEREDA DE PUENTE | 3d | 2012-11-08 | 2012-11-11 | 47 | 21d |  | CAPATAZ [9.6%]; OFICIAL [96%]; PEON [96%]; ALAMBRE NEGRO RECOCIDO # 16 [864%]; TUBO PVC SAP D= 6" CLASE 5 [17280%] | 48.37h | 5,400 | 01.07.07.03 | 000000000000046 | 172.8 | 31.25 | 5400 | 60 |
| 46 | 1.7.7.4 | FABRICACION Y COLOCACION DE BARANDAS METALICAS (INCLUYE PINTURA) | 6d | 2012-11-11 | 2012-11-17 | 29 | 15d |  | DISOLVENTE PARA PINTURA ESMALTE POLIURETANO [133.1%]; DISOLVENTE PARA PINTURA EPOXICO [86.5%]; PINTURA DE RESINA EPOXICA [432.4%]; PINTURA DE POLIURETANO ALIFATICA AMERSHIEL O SIMILAR [232.8%]; CAPATAZ [48.8%]; OPERARIO [155.1%]; OFICIAL [88.7%]; PEON [561.4%]; SOLDADORA ELECTRICA TRIFASICA 400 A [48%]; EQUIPO DE OXICORTE [48%]; EQUIPO DE PINTURA AIRLESS [29.6%]; GRUPO ELECTROGENO 140 HP 90 KW [29.6%]; SOLDADURA AWS E7018 O SIMILAR [30240%]; TUBO DE FIERRO 3" SCH-40 [9072%]; TUBO DE FIERRO 2" SCH-40 [18144%]; PLATINA DE ACERO 3/8" X 0.125 X 2.20 m [1987.2%]; PLATINA DE ACERO 3/8" (B3) [777.6%]; OXIGENO [5184%]; ACETILENO [1728%]; PERNO DE ANCLAJE 5/8" X 0.50 m [27648%]; PLANCHA DE ACERO 5/8" x 0.20 x 0.17 m. [6912%] | 726.59h | 35,842.18 | 01.07.07.04 | 000000000000047 | 86.4 | 414.84 | 35842.18 | 10 |
| 47 | 1.7.7.5 | TUBO DE DRENAJE , D= 4" @ 5.0m | 2d | 2012-11-06 | 2012-11-08 | 29SS | 21d | 0d | CAPATAZ [10%]; OPERARIO; PEON; ALAMBRE NEGRO RECOCIDO # 16 [500%]; TUBO PVC SAP D=4" [1500%]; CODO PVC SAP 4"X45º [2000%] | 33.6h | 1,230 | 01.07.07.05 | 000000000000048 | 20 | 61.5 | 1230 | 10 |
| 48 | 1.7.7.6 | JUNTA DE DILATACION EN PUENTE | 1d | 2012-08-15 | 2012-08-16 | 74 | 109d |  | CAPATAZ [14.4%]; OPERARIO [144%]; PEON [72%]; CONCRETO POLIMERICO [11160%]; ADHESIVO EPÓXICO DE FIJACION [1152%]; IMPRIMANTE DE ADHESIVO EPOXICO [149%]; JUNTA ELASTOMERICA ESTRUCTURAL [1512%]; ESPUMA SINTETICA DE POLIERAETANO (TEKNOPORT) e=2" [72%]; PEGAMENTO PARA NEOPRENO [144%] | 36.86h | 13,488.62 | 01.07.07.06 | 000000000000049 | 14.4 | 936.71 | 13488.62 | 10 |
| 49 | 2 | **PROTECCION RIBEREÑA** | 73d | 2012-09-06 | 2012-11-18 |  | 15d |  |  | 18926.5h | 555,090.81 | 02 | 000000000000050 |  |  |  |  |
| 50 | 2.1 | RELLENO COMPACTADO CON MATERIAL PROPIO | 47d | 2012-09-26 | 2012-11-12 | 52SS+20d | 20d |  | CAPATAZ [10%]; OFICIAL; PEON [405.2%]; CAMION CISTERNA 4 X 2 (AGUA) 122 HP 2 000 gl [6%]; COMPACTADOR VIBRATORIO TIPO PLANCHA 7 HP; RODILLO LISO VIBRATORIO MANUAL 10.8HP 0.8-1.1 ton [199.6%] | 3084.33h | 56,655.2 | 02.01 | 000000000000051 | 2345 | 24.16 | 56655.2 | 50 |
| 51 | 2.2 | GEOTEXTIL NO TEJIDO EN MUROS DE CONTENCIÓN | 15d | 2012-09-06 | 2012-09-21 | 52SS | 72d |  | CAPATAZ [96.7%]; OFICIAL [96.7%]; PEON [193.4%]; GEOTEXTIL NO TEJIDO CLASE 2 [425590%] | 495.23h | 18,184.3 | 02.02 | 000000000000052 | 3869 | 4.7 | 18184.3 | 250 |
| 52 | 2.3 | GAVIONES | 73d | 2012-09-06 | 2012-11-18 | 38FS-10d | 15d | 0d | CAPATAZ [10%]; OPERARIO [0%]; OFICIAL [103.5%]; PEON [1169.6%]; CAMION VOLQUETE 15 m3 [26.6%]; TRACTOR DE ORUGAS DE 140 -160 HP [0.4%]; CARGADOR SOBRE LLANTAS 125-155 HP 3 yd3 [3.7%]; GAVION CAJA FUERTE DE 5 m x 1 m x1m ( Malla 10 x12 cm ;2.7 mm) REVESTIDO CON PVC [20110%]; GAVION TIPO COLCHON 5 m x 2 m x 0.50m ( Malla 10 x12 cm ;2.7 mm) REVESTIDO CON PVC [13406.7%]; GAVION CAJA FUERTE DE 5 m x 1 m x1.5m ( Malla 10 x12 cm ;2.7 mm) REVESTIDO CON PVC [20110%] | 15346.9h | 480,251.31 | 02.03 | 000000000000053 | 2914.5 | 164.78 | 480251.31 | 20 |

| ID | WBS | Task | Duration | Start | Finish | Predecessors | Total slack | Free slack | Resources | Work | Cost | Text1 | Text8 | Text2 | Text3 | Text4 | Text6 |
| --- | --- | --- | --- | --- | --- | --- | --- | --- | --- | --- | --- | --- | --- | --- | --- | --- | --- |
| 53 | 3 | **ACCESOS** | 177d? | 2012-06-01 | 2012-11-25 |  | 8d |  |  | 63503.5h | 2,636,877.39 | 03 | 000000000000054 |  |  |  |  |
| 54 | 3.1 | **MOVIMIENTO DE TIERRAS** | 10d | 2012-06-07 | 2012-06-17 |  | 26d |  |  | 780.06h | 44,975.63 | 03.01 | 000000000000055 |  |  |  |  |
| 55 | 3.1.1 | DESBROCE Y LIMPIEZA EN ZONA NO BOSCOSA | 1d | 2012-06-07 | 2012-06-08 | 4SS+5d | 26d | 0d | CAPATAZ [48%]; OPERARIO [96%]; PEON [96%]; MOTOSIERRA [96%]; TRACTOR DE ORUGAS DE 140 -160 HP [48%] | 30.72h | 1,275.08 | 03.01.01 | 000000000000056 | 0.48 | 2656.42 | 1275.08 |  |
| 56 | 3.1.2 | REMOCION DE REVESTIMIENTO ASFALTICO EXISTENTE, IMPRIMACION REFORZADA e =2.5 cm | 1d | 2012-06-08 | 2012-06-09 | 55 | 26d | 0d | CAPATAZ [14.8%]; OFICIAL [76.7%]; PEON [76.7%]; MOTONIVELADORA DE 145-150 HP [76.7%] | 19.59h | 1,321.73 | 03.01.02 | 000000000000057 | 2360.23 | 0.56 | 1321.73 | 3110 |
| 57 | 3.1.3 | LAVADO DE AGREGADOS DE RIO | 8d | 2012-06-09 | 2012-06-17 | 56 | 26d | 0d | CAPATAZ [9.5%]; OPERARIO [93.7%]; PEON [187.8%]; MOTOBOMBA 34 HP 8" [267.5%]; CARGADOR SOBRE LLANTAS 125-155 HP 3 yd3 [79.9%]; LAVADORA GUSANO EJE SIMPLE D=48" [93.7%]; GRUPO ELECTROGENO 230 HP 150 KW [93.7%]; FAJA TRANSPORTADORA 18" X 4' MOTOR ELECTRICO 3 KW 150 ton/h [187.8%] | 729.75h | 42,378.82 | 03.01.03 | 000000000000058 | 3242.45 | 13.07 | 42378.82 | 384 |
| 58 | 3.2 | **PAVIMENTO ASFALTICO** | 12d | 2012-11-11 | 2012-11-23 |  | 7d |  |  | 955.93h | 71,007.26 | 03.02 | 000000000000059 |  |  |  |  |
| 59 | 3.2.1 | SUB BASE GRANULAR (e= 0.15 m) | 1d | 2012-11-11 | 2012-11-12 | 29 | 10d | 0d | CAPATAZ [119.1%]; OFICIAL; PEON [799.3%]; CAMION CISTERNA 4 X 2 (AGUA) 122 HP 2 000 gl [34.9%]; CAMION VOLQUETE 15 m3 [106.8%]; RODILLO LISO VIBRATORIO AUTOPROPULSADO 101-135HP 10-12 ton [64.4%]; TRACTOR DE ORUGAS DE 140 -160 HP [11.3%]; CARGADOR SOBRE LLANTAS 125-155 HP 3 yd3 [142.4%]; RETROEXCAVADORA SOBRE ORUGAS 115-165 HP -1.4 yd3 (1.10 m3) [44.9%]; MOTONIVELADORA DE 145-150 HP [64.4%]; ZARANDA ESTATICA [98.6%] | 253.78h | 16,654.12 | 03.02.01 | 000000000000060 | 578.67 | 28.78 | 16654.12 | 450 |
| 60 | 3.2.2 | BASE GRANULAR (e= 0.20 m) | 2d | 2012-11-12 | 2012-11-14 | 59 | 10d | 3d | CAPATAZ [171.2%]; OFICIAL [158.6%]; PEON [1206.6%]; CAMION CISTERNA 4 X 2 (AGUA) 122 HP 2 000 gl [46.5%]; CAMION VOLQUETE 15 m3 [264.5%]; RODILLO LISO VIBRATORIO AUTOPROPULSADO 101-135HP 10-12 ton [81%]; TRACTOR DE ORUGAS DE 140 -160 HP [18.7%]; CARGADOR SOBRE LLANTAS 125-155 HP 3 yd3 [228.5%]; RETROEXCAVADORA SOBRE ORUGAS 115-165 HP -1.4 yd3 (1.10 m3) [73.9%]; MOTONIVELADORA DE 145-150 HP [81%]; ZARANDA ESTATICA [162.5%] | 398.87h | 29,080.47 | 03.02.02 | 000000000000061 | 771.57 | 37.69 | 29080.47 | 476 |
| 61 | 3.2.3 | COLOCACION MANUAL DE MORTERO ASFALTICO (SLURRY SEAL e=6mm) | 6d | 2012-11-17 | 2012-11-23 | 60, 73, 29FS+6d | 7d | 0d | CEMENTO PORTLAND TIPO I (42.5 kg) [23961.6%]; EMULSION ASFALTICA SUPER ESTABLE [163662%]; CAPATAZ [47.9%]; OFICIAL [189.8%]; PEON [384.4%]; CAMION CISTERNA 4 X 2 (AGUA) 122 HP 2 000 gl [0.5%]; CAMION VOLQUETE 15 m3 [5.1%]; CARGADOR SOBRE LLANTAS 125-155 HP 3 yd3 [2.1%]; RETROEXCAVADORA SOBRE ORUGAS 115-165 HP -1.4 yd3 (1.10 m3) [0.7%]; ZARANDA ESTATICA [1.4%] | 303.29h | 25,272.67 | 03.02.03 | 000000000000062 | 4521.05 | 5.59 | 25272.67 | 800 |
| 62 | 3.3 | **OBRAS DE ARTE** | 120d | 2012-06-08 | 2012-10-06 |  | 58d |  |  | 5657.6h | 295,796.26 | 03.03 | 000000000000063 |  |  |  |  |
| 63 | 3.3.1 | EXCAVACION DE MATERIAL SUELTO | 5d | 2012-06-08 | 2012-06-13 | 55 | 165d | 0d | CAPATAZ [9.7%]; OFICIAL [96.8%]; PEON [386.2%]; RETROEXCAVADORA SOBRE ORUGAS 115-165 HP -1.4 yd3 (1.10 m3) [96.8%] | 660.22h | 30,147.55 | 03.03.01 | 000000000000064 | 4732.74 | 6.37 | 30147.55 | 350 |
| 64 | 3.3.2 | RELLENO COMPACTADO CON MATERIAL PROPIO | 29d | 2012-06-27 | 2012-07-26 | 67SS+10d | 130d | 128d | CAPATAZ [9.8%]; OFICIAL [98%]; PEON [397.8%]; CAMION CISTERNA 4 X 2 (AGUA) 122 HP 2 000 gl [5.9%]; COMPACTADOR VIBRATORIO TIPO PLANCHA 7 HP [98%]; RODILLO LISO VIBRATORIO MANUAL 10.8HP 0.8-1.1 ton [196%] | 1933.15h | 35,509.4 | 03.03.02 | 000000000000065 | 1469.76 | 24.16 | 35509.4 | 50 |
| 65 | 3.3.3 | RELLENO COMPACTADO CON MATERIAL ESPECIFICADO | 8d | 2012-09-28 | 2012-10-06 | 67FS-3d | 26d | 0d | CAPATAZ [187.4%]; OFICIAL [301.5%]; PEON [2039.3%]; CAMION CISTERNA 4 X 2 (AGUA) 122 HP 2 000 gl [113.4%]; CAMION VOLQUETE 15 m3 [442.2%]; RODILLO LISO VIBRATORIO AUTOPROPULSADO 101-135HP 10-12 ton [91.7%]; TRACTOR DE ORUGAS DE 140 -160 HP [82.7%]; CARGADOR SOBRE LLANTAS 125-155 HP 3 yd3 [439.4%]; RETROEXCAVADORA SOBRE ORUGAS 115-165 HP -1.4 yd3 (1.10 m3) [145.9%]; MOTONIVELADORA DE 145-150 HP [91.7%]; ZARANDA ESTATICA [320.6%] | 3064.24h | 230,139.31 | 03.03.03 | 000000000000066 | 8467.23 | 27.18 | 230139.31 | 1020 |
| 66 | 3.4 | **ENCOFRADO Y DESENCOFRADO** | 134d | 2012-06-17 | 2012-10-29 |  | 26d |  |  | 14483.4h | 346,802.76 | 03.04 | 000000000000067 |  |  |  |  |
| 67 | 3.4.1 | ENCOFRADO Y DESENCOFRADO DE ESTRIBOS Y MUROS DE CONTENCIÓN | 106d | 2012-06-17 | 2012-10-01 | 72SS | 26d | 0d | LACA DESMOLDANTE [29620.4%]; CAPATAZ [4228.3%]; OPERARIO [42312.7%]; OFICIAL [42312.7%]; PEON [84632.9%]; ALAMBRE NEGRO RECOCIDO # 8 [118482%]; CLAVOS DIFERENTES MEDIDAS [118482%]; MADERA TORNILLO [912308%]; TRIPLAY DE 19 mm [71089%] | 13878.9h | 331,215.31 | 03.04.01 | 000000000000068 | 5924.08 | 55.91 | 331215.31 | 14 |
| 68 | 3.4.2 | ENCOFRADO Y DESENCOFRADO CARAVISTA EN LOSAS Y VEREDA | 18d | 2012-10-11 | 2012-10-29 | 65FS+5d | 26d | 0d | LACA DESMOLDANTE [1105.7%]; CAPATAZ [9.7%]; OPERARIO [97%]; OFICIAL [97%]; PEON [194%]; ALAMBRE NEGRO RECOCIDO # 8 [4422.6%]; CLAVOS DIFERENTES MEDIDAS [4422.6%]; MADERA TORNILLO [79385.7%]; TRIPLAY DE 19 mm [2653.6%] | 604.44h | 15,587.45 | 03.04.02 | 000000000000069 | 221.13 | 70.49 | 15587.45 | 12 |
| 69 | 3.5 | **ACERO DE REFUERZO** | 100d | 2012-06-18 | 2012-09-26 |  | 54d |  |  | 17763.1h | 778,924.49 | 03.05 | 000000000000070 |  |  |  |  |
| 70 | 3.5.1 | ACERO DE REFUERZO fy=4200 kg/cm2 | 100d | 2012-06-18 | 2012-09-26 | 72SS+1d | 54d | 0d | CAPATAZ [7162.5%]; OPERARIO [71625.2%]; OFICIAL [71625.2%]; PEON [71625.2%]; ALAMBRE NEGRO RECOCIDO # 16 [895316%]; ACERO CORRUGADO fy=4200 kg/cm2 GRADO 60 | 17763.1h | 778,924.49 | 03.05.01 | 000000000000071 | 179063.1 | 4.35 | 778924.49 | 250 |
| 71 | 3.6 | **CONCRETO** | 134d? | 2012-06-17 | 2012-10-29 |  | 26d |  |  | 15136.2h | 653,415.62 | 03.06 | 000000000000072 |  |  |  |  |
| 72 | 3.6.1 | CONCRETO CLASE H ( f'c = 100 kg/cm2 ) | 10d? | 2012-06-17 | 2012-06-27 | 57 | 26d | 0d | CEMENTO PORTLAND TIPO I (42.5 kg) [76729.5%]; ADITIVO CURADOR [3239.7%]; COMBUSTIBLE [4774.3%]; CAPATAZ [51.1%]; OPERARIO [284.2%]; OFICIAL [290%]; PEON [605.9%]; MEZCLADORA DE CONCRETO DE 11p3 18 HP [94.7%]; CAMION CISTERNA 4 X 2 (AGUA) 122 HP 2 000 gl [3.7%]; CAMION VOLQUETE 15 m3 [19.4%]; CARGADOR SOBRE LLANTAS 125-155 HP 3 yd3 [9.2%]; RETROEXCAVADORA SOBRE ORUGAS 115-165 HP -1.4 yd3 (1.10 m3) [3.4%]; VIBRADOR DE CONCRETO 4 HP 2.40" [94.7%]; ZARANDA ESTATICA [6.7%] | 1170.48h | 36,884.72 | 03.06.01 | 000000000000073 | 170.51 | 216.32 | 36884.72 | 18 |
| 73 | 3.6.2 | CONCRETO CLASE E (f'c=175 kg/cm2) | 5d | 2012-10-24 | 2012-10-29 | 68FF, 70, 72, 74 | 26d | 0d | CEMENTO PORTLAND TIPO I (42.5 kg) [64035%]; ADITIVO CURADOR [1451.5%]; COMBUSTIBLE [2390.6%]; CAPATAZ [51.1%]; OPERARIO [284.6%]; OFICIAL [290.5%]; PEON [606.8%]; MEZCLADORA DE CONCRETO DE 11p3 18 HP [94.9%]; CAMION CISTERNA 4 X 2 (AGUA) 122 HP 2 000 gl [3.7%]; CAMION VOLQUETE 15 m3 [19.4%]; CARGADOR SOBRE LLANTAS 125-155 HP 3 yd3 [9.2%]; RETROEXCAVADORA SOBRE ORUGAS 115-165 HP -1.4 yd3 (1.10 m3) [3.4%]; VIBRADOR DE CONCRETO 4 HP 2.40" [94.9%]; ZARANDA ESTATICA [6.8%] | 586.1h | 23,445.35 | 03.06.02 | 000000000000074 | 85.38 | 274.6 | 23445.35 | 18 |
| 74 | 3.6.3 | CONCRETO CLASE D (f'c=210 kg/cm2) | 54d | 2012-06-22 | 2012-08-15 | 70SS+4d | 59d | 0d | CEMENTO PORTLAND TIPO I (42.5 kg); ADITIVO CURADOR [37032.5%]; COMBUSTIBLE [54574.2%]; CAPATAZ [53.6%]; OPERARIO [298%]; OFICIAL [304.2%]; PEON [635.4%]; MEZCLADORA DE CONCRETO DE 11p3 18 HP [99.3%]; CAMION CISTERNA 4 X 2 (AGUA) 122 HP 2 000 gl [3.9%]; CAMION VOLQUETE 15 m3 [20.3%]; CARGADOR SOBRE LLANTAS 125-155 HP 3 yd3 [9.6%]; RETROEXCAVADORA SOBRE ORUGAS 115-165 HP -1.4 yd3 (1.10 m3) [3.6%]; VIBRADOR DE CONCRETO 4 HP 2.40" [99.3%]; ZARANDA ESTATICA [7.1%] | 13379.6h | 593,085.55 | 03.06.03 | 000000000000075 | 1949.08 | 304.29 | 593085.55 | 18 |
| 75 | 3.7 | **DETALLES EN TABLERO** | 61d | 2012-08-05 | 2012-10-05 |  | 59d |  |  | 5299.5h | 244,709.62 | 03.07 | 000000000000076 |  |  |  |  |
| 76 | 3.7.1 | ACABADO DE VEREDAS INC. BRUÑAS | 33d | 2012-08-05 | 2012-09-07 | 74FS-10d | 59d | 0d | CEMENTO PORTLAND TIPO I (42.5 kg) [5692.2%]; CAPATAZ [9.8%]; OPERARIO [97.9%]; OFICIAL [0.1%]; PEON [98.3%]; CAMION CISTERNA 4 X 2 (AGUA) 122 HP 2 000 gl [0.1%]; CAMION VOLQUETE 15 m3 [0.3%]; CARGADOR SOBRE LLANTAS 125-155 HP 3 yd3 [0.1%]; RETROEXCAVADORA SOBRE ORUGAS 115-165 HP -1.4 yd3 (1.10 m3) [0%]; ZARANDA ESTATICA [0.1%] | 512.51h | 8,570.25 | 03.07.01 | 000000000000077 | 455.38 | 18.82 | 8570.25 | 15 |
| 77 | 3.7.2 | FABRICACION Y COLOCACION DE BARANDAS METALICAS (INCLUYE PINTURA) | 38d | 2012-08-28 | 2012-10-05 | 76FS-10d | 59d |  | DISOLVENTE PARA PINTURA ESMALTE POLIURETANO [876.6%]; DISOLVENTE PARA PINTURA EPOXICO [569.8%]; PINTURA DE RESINA EPOXICA [2849%]; PINTURA DE POLIURETANO ALIFATICA AMERSHIEL O SIMILAR [1534.1%]; CAPATAZ [50.7%]; OPERARIO [161.4%]; OFICIAL [92.3%]; PEON [584%]; SOLDADORA ELECTRICA TRIFASICA 400 A [49.9%]; EQUIPO DE OXICORTE [49.9%]; EQUIPO DE PINTURA AIRLESS [30.8%]; GRUPO ELECTROGENO 140 HP 90 KW [30.8%]; SOLDADURA AWS E7018 O SIMILAR [199230%]; TUBO DE FIERRO 3" SCH-40 [59769.2%]; TUBO DE FIERRO 2" SCH-40 [119538%]; PLATINA DE ACERO 3/8" X 0.125 X 2.20 m [13092.3%]; PLATINA DE ACERO 3/8" (B3) [5123.1%]; OXIGENO [34153.8%]; ACETILENO [11384.6%]; PERNO DE ANCLAJE 5/8" X 0.50 m [182154%]; PLANCHA DE ACERO 5/8" x 0.20 x 0.17 m. [45538.4%] | 4787h | 236,139.37 | 03.07.02 | 000000000000078 | 569.23 | 414.84 | 236139.37 | 10 |

| ID | WBS | Task | Duration | Start | Finish | Predecessors | Total slack | Free slack | Resources | Work | Cost | Text1 | Text8 | Text2 | Text3 | Text4 | Text6 |
| --- | --- | --- | --- | --- | --- | --- | --- | --- | --- | --- | --- | --- | --- | --- | --- | --- | --- |
| 78 | 3.8 | **DETALLE EN MUROS DE CONTENCION Y VEREDAS DE ACCESOS** | 132d | 2012-06-20 | 2012-10-30 |  | 34d |  |  | 1875.19h | 134,841.16 | 03.08 | 000000000000079 |  |  |  |  |
| 79 | 3.8.1 | GEOTEXTIL NO TEJIDO EN MUROS DE CONTENCIÓN | 8d | 2012-06-20 | 2012-06-28 | 67SS+3d | 157d |  | CAPATAZ [90.3%]; OFICIAL [90.3%]; PEON [180.5%]; GEOTEXTIL NO TEJIDO CLASE 2 [223381%] | 259.93h | 9,544.48 | 03.08.01 | 000000000000080 | 2030.74 | 4.7 | 9544.48 | 250 |
| 80 | 3.8.2 | TUBO DE DRENAJE PVC SAP, D= 2" x 0.40m EN MUROS DE CONTENCION | 2d | 2012-06-20 | 2012-06-22 | 67SS+3d | 163d |  | CAPATAZ [8.9%]; OFICIAL [89%]; PEON [89%]; ALAMBRE NEGRO RECOCIDO # 16 [10680%]; TUBO PVC SAP D=2" [9612%] | 29.93h | 1,170.53 | 03.08.02 | 000000000000081 | 213.6 | 5.48 | 1170.53 | 120 |
| 81 | 3.8.3 | TUBO DE DRENAJE HDPE, D= 4" x 0.65m EN MUROS DE CONTENCIÓN | 1d | 2012-06-22 | 2012-06-23 | 67SS+5d | 162d | 38d | CAPATAZ [7.8%]; OPERARIO [78%]; PEON [78%]; TUBO SIN PERFORAR HDPE D=4" [4563%] | 13.11h | 517.37 | 03.08.03 | 000000000000082 | 70.2 | 7.37 | 517.37 | 90 |
| 82 | 3.8.4 | TUBO DE HDPE PERFORADO, D= 4" EN MUROS DE CONTENCIÓN | 6d | 2012-07-25 | 2012-07-31 | 67SS+7d, 81FF, 83FF | 124d |  | CAPATAZ [10%]; OPERARIO; PEON; TUBO HDPE PERFORADO D=4" [53940%] | 100.71h | 5,545.03 | 03.08.04 | 000000000000083 | 539.4 | 10.28 | 5545.03 | 90 |
| 83 | 3.8.5 | JUNTAS DE CONTRACCION EN MUROS DE CONTENCION | 41d | 2012-06-20 | 2012-07-31 | 67SS+3d, 84FF | 124d | 0d | LACA DESMOLDANTE [81102.3%]; CAPATAZ [9.9%]; OPERARIO [98.9%]; PEON [98.9%]; CLAVOS DIFERENTES MEDIDAS [324409%]; TIRAS DE MADERA TORNILLO SEMICIRCULAR D=2 cm [851574%] | 1362.52h | 115,084.16 | 03.08.05 | 000000000000084 | 8110.23 | 14.19 | 115084.16 | 100 |
| 84 | 3.8.6 | JUNTAS DE DILATACION EN MUROS DE CONTENCION | 10d | 2012-06-25 | 2012-07-05 | 67SS+8d | 150d | 26d | CAPATAZ [9.3%]; PEON [93.5%]; PLANCHA DE TECKNOPOR DE 1" X 4' X 8' [14810%] | 90.51h | 2,669.92 | 03.08.06 | 000000000000085 | 411.39 | 6.49 | 2669.92 | 40 |
| 85 | 3.8.7 | JUNTAS DE DILATACION EN VEREDAS DE ACCESOS | 1d | 2012-10-29 | 2012-10-30 | 76, 73 | 34d |  | ASFALTO RC-250 [124.2%]; CAPATAZ [10.4%]; OPERARIO [51.8%]; OFICIAL [51.9%]; PEON [0.7%]; CAMION VOLQUETE 15 m3 [0.5%]; CARGADOR SOBRE LLANTAS 125-155 HP 3 yd3 [0.2%]; RETROEXCAVADORA SOBRE ORUGAS 115-165 HP -1.4 yd3 (1.10 m3) [0.1%]; ZARANDA ESTATICA [0.1%] | 18.49h | 309.67 | 03.08.07 | 000000000000086 | 82.8 | 3.74 | 309.67 | 80 |
| 86 | 3.9 | **VARIOS** | 26d | 2012-06-01 | 2012-06-27 |  | 157d |  |  | 1341.37h | 34,842.07 | 03.09 | 000000000000087 |  |  |  |  |
| 87 | 3.9.1 | SUMINISTRO E INSTALACION TUBERIA TMC D=36" | 2d | 2012-06-25 | 2012-06-27 | 67SS+8d | 159d |  | CAPATAZ [8.3%]; OFICIAL [79.7%]; PEON [477.7%]; CAMION CISTERNA 4 X 2 (AGUA) 122 HP 2 000 gl [0.3%]; CAMION VOLQUETE 15 m3 [2.4%]; CARGADOR SOBRE LLANTAS 125-155 HP 3 yd3 [1%]; RETROEXCAVADORA SOBRE ORUGAS 115-165 HP -1.4 yd3 (1.10 m3) [0.3%]; ZARANDA ESTATICA [0.7%]; TUBERIA METALICA CORRUGADA TIPO ARMCO D=36" [2844%] | 136.88h | 11,592.71 | 03.09.01 | 000000000000088 | 28.44 | 407.62 | 11592.71 | 12 |
| 88 | 3.9.2 | EMBOQUILLADO DE PIEDRA e=15cm | 23d | 2012-06-01 | 2012-06-24 |  | 157d | 122d | CEMENTO PORTLAND TIPO I (42.5 kg) [14466.3%]; ADITIVO CURADOR [206.7%]; COMBUSTIBLE [248%]; CAPATAZ [22.6%]; OPERARIO [214.6%]; OFICIAL [16.3%]; PEON [385.6%]; MEZCLADORA DE CONCRETO DE 11p3 18 HP [5%]; CAMION CISTERNA 4 X 2 (AGUA) 122 HP 2 000 gl [0.2%]; CAMION VOLQUETE 15 m3 [8.2%]; CARGADOR SOBRE LLANTAS 125-155 HP 3 yd3 [1.5%]; RETROEXCAVADORA SOBRE ORUGAS 115-165 HP -1.4 yd3 (1.10 m3) [0.2%]; ZARANDA ESTATICA [0.4%] | 1204.49h | 23,249.36 | 03.09.02 | 000000000000089 | 688.87 | 33.75 | 23249.36 | 30 |
| 89 | 3.10 | **TRANSPORTE** | 10d | 2012-06-10 | 2012-06-20 |  | 165d |  |  | 164.95h | 27,087.34 | 03.10 | 000000000000090 |  |  |  |  |
| 90 | 3.10.1 | TRANSPORTE DE DESECHOS Y MATERIAL EXCEDENTE A DME ; D =300 m | 3d | 2012-06-10 | 2012-06-13 | 63FF, 103 | 168d | 0d | OFICIAL [49.4%]; CAMION VOLQUETE 15 m3 [81.3%]; CARGADOR SOBRE LLANTAS 125-155 HP 3 yd3 [49.4%] | 72.09h | 12,008.99 | 03.10.01 | 000000000000091 | 1594.82 | 7.53 | 12008.99 | 392 |
| 91 | 3.10.2 | TRANSPORTE DE MATERIAL EXCEDENTE A DEFENSA RIBEREÑA, D=100 m | 7d | 2012-06-13 | 2012-06-20 | 63 | 165d |  | OFICIAL [66.8%]; CAMION VOLQUETE 15 m3 [98.5%]; CARGADOR SOBRE LLANTAS 125-155 HP 3 yd3 [66.8%] | 92.86h | 15,078.35 | 03.10.02 | 000000000000092 | 2345 | 6.43 | 15078.35 | 475 |
| 92 | 3.11 | **SEÑALIZACION Y SEGURIDAD VIAL** | 2d | 2012-11-23 | 2012-11-25 |  | 7d |  |  | 46.3h | 4,475.18 | 03.11 | 000000000000093 |  |  |  |  |
| 93 | 3.11.1 | SEÑALES PREVENTIVAS (0.60 M X 0.60 M) P2A | 1d | 2012-11-23 | 2012-11-24 | 61 | 7d | 0d | CEMENTO PORTLAND TIPO I (42.5 kg) [85.8%]; ADITIVO CURADOR [1.2%]; COMBUSTIBLE [1.5%]; DISOLVENTE XILOL [2.7%]; PINTURA ANTICORROSIVA [1.6%]; TINTA SERIGRAFICA NEGRA O ROJA [1.6%]; PINTURA ESMALTE SINTETICO [1.6%]; CAPATAZ [4.3%]; OPERARIO [28.7%]; OFICIAL [18.8%]; PEON [36%]; MEZCLADORA DE CONCRETO DE 11p3 18 HP [0.7%]; CAMION CISTERNA 4 X 2 (AGUA) 122 HP 2 000 gl [0%]; CAMION VOLQUETE 15 m3 [0.2%]; SOLDADORA ELECTRICA TRIFASICA 400 A [16.7%]; CARGADOR SOBRE LLANTAS 125-155 HP 3 yd3 [0.1%]; RETROEXCAVADORA SOBRE ORUGAS 115-165 HP -1.4 yd3 (1.10 m3) [0%]; ZARANDA ESTATICA [0%]; SOLDADURA AWS E6011 [8%]; ANGULO DE ACERO 1" X 1" X 3/16" [240%]; PLATINA DE ACERO 2" X 1/8" [154%]; TUBO DE FIERRO GALVANIZADO D= 2" esp=2.5mm [360%]; FIBRA DE VIDRIO DE 4 mm ACABADO [36%]; LAMINA REFLECTIVA ALTA INTENSIDAD [388%]; PERNOS 1/4" X 3" [200%] | 8.43h | 341.18 | 03.11.01 | 000000000000094 |  | 341.18 | 341.18 |  |
| 94 | 3.11.2 | SEÑALES PREVENTIVAS (0.60 M X 0.60 M) P2B | 1d | 2012-11-23 | 2012-11-24 | 93SS | 7d | 0d | DISOLVENTE XILOL [2.7%]; PINTURA ANTICORROSIVA [1.6%]; TINTA SERIGRAFICA NEGRA O ROJA [2.3%]; PINTURA ESMALTE SINTETICO [1.6%]; CAPATAZ [4.6%]; OPERARIO [29.2%]; OFICIAL [29.2%]; SOLDADORA ELECTRICA TRIFASICA 400 A [16.7%]; SOLDADURA AWS E6011 [8%]; ANGULO DE ACERO 1" X 1" X 3/16" [240%]; PLATINA DE ACERO 2" X 1/8" [154%]; TUBO DE FIERRO GALVANIZADO D= 2" esp=2.5mm [411%]; FIBRA DE VIDRIO DE 4 mm ACABADO [36%]; LAMINA REFLECTIVA ALTA INTENSIDAD [388%]; PERNOS 1/4" X 3" [200%]; PLANCHA METALICA ASTM A36 e=1/4" 0.125 m x 0.125 m. [200%]; PERNO AUTOEXPANSIVOS TIPO CUÑA 3/8" X 5" [800%] | 6.37h | 362.35 | 03.11.02 | 000000000000095 |  | 362.35 | 362.35 |  |
| 95 | 3.11.3 | SEÑALES REGULADORAS (0.60 M X 0.90 M) (doble) | 1d | 2012-11-23 | 2012-11-24 | 93SS | 7d | 0d | DISOLVENTE XILOL [5.4%]; PINTURA ANTICORROSIVA [3.2%]; TINTA SERIGRAFICA NEGRA O ROJA [12%]; PINTURA ESMALTE SINTETICO [3.2%]; CAPATAZ [9.2%]; OPERARIO [58.3%]; OFICIAL [58.3%]; SOLDADORA ELECTRICA TRIFASICA 400 A [33.3%]; SOLDADURA AWS E6011 [20%]; ANGULO DE ACERO 1" X 1" X 3/16" [1200%]; PLATINA DE ACERO 2" X 1/8" [572%]; TUBO DE FIERRO GALVANIZADO D= 2" esp=2.5mm [1032%]; FIBRA DE VIDRIO DE 4 mm ACABADO [216%]; LAMINA REFLECTIVA ALTA INTENSIDAD [2326%]; PERNOS 1/4" X 3" [800%]; PLANCHA METALICA ASTM A36 e=1/4" 0.125 m x 0.125 m. [400%]; PERNO AUTOEXPANSIVOS TIPO CUÑA 3/8" X 5" [1600%] | 12.73h | 1,250.84 | 03.11.03 | 000000000000096 |  | 625.42 | 1250.84 |  |
| 96 | 3.11.4 | SEÑALES INFORMATIVAS (1.26 M X 0.67 M) | 1d | 2012-11-24 | 2012-11-25 | 93, 94, 95 | 7d |  | PINTURA ANTICORROSIVA [16.9%]; TINTA SERIGRAFICA NEGRA O ROJA [42.2%]; PINTURA ESMALTE SINTETICO [16.9%]; CAPATAZ [5.6%]; OPERARIO [42.2%]; OFICIAL [42.2%]; SOLDADURA AWS E6011 [13.5%]; ANGULO DE ACERO 1" X 1" X 3/16" [777.4%]; PLATINA DE ACERO 2" X 1/8" [486.7%]; TUBO DE FIERRO GALVANIZADO D= 2" esp=2.5mm [1761%]; FIBRA DE VIDRIO DE 4 mm ACABADO [170.7%]; LAMINA REFLECTIVA ALTA INTENSIDAD [1828.6%]; PERNOS 1/4" X 3" [804.4%]; PLANCHA METALICA ASTM A36 e=1/4" 0.125 m x 0.125 m. [402.2%]; PERNO AUTOEXPANSIVOS TIPO CUÑA 3/8" X 5" [1352%] | 7.21h | 1,519.8 | 03.11.04 | 000000000000097 | 1.69 | 899.29 | 1519.8 |  |
| 97 | 3.11.5 | MARCAS EN EL PAVIMENTO | 1d | 2012-11-23 | 2012-11-24 | 61 | 8d | 0d | DISOLVENTE XILOL [63.1%]; PINTURA PARA TRAFICO TTP-115F COLOR AMARILLO [631.5%]; CAPATAZ [3.9%]; OPERARIO [7.9%]; PEON [31.6%]; MAQUINARIA PARA PINTAR MARCAS EN PAVIMENTOS [7.9%]; MICROESFERAS DE VIDRIO [2210.2%] | 4.1h | 433.84 | 03.11.05 | 000000000000098 | 63.15 | 6.87 | 433.84 | 800 |
| 98 | 3.11.6 | DEMARCACION DE OBSTACULO (PINTURA EN BORDE DE VEREDA DE ACCESO A PUENTE) | 1d | 2012-11-24 | 2012-11-25 | 97 | 8d | 6d | DISOLVENTE XILOL [114.6%]; PINTURA ESMALTE SINTETICO [572.9%]; PINTURA PARA TRAFICO TTP-115F COLOR AMARILLO [572.9%]; CAPATAZ [7.2%]; OPERARIO [14.3%]; PEON [57.3%]; MAQUINARIA PARA PINTAR MARCAS EN PAVIMENTOS [14.3%] | 7.45h | 567.17 | 03.11.06 | 000000000000099 | 114.58 | 4.95 | 567.17 | 800 |
| 99 | 4 | **PLAN DE MANEJO SOCIO AMBIENTAL** | 185d? | 2012-06-01 | 2012-12-03 |  | 0d |  |  | 980.82h | 97,582.31 | 04 | 000000000000100 |  |  |  |  |
| 100 | 4.1 | **PROGRAMA DE CAPACITACIÓN Y MANEJO AMBIENTAL** | 175d | 2012-06-01 | 2012-11-23 |  | 10d |  |  | 8h | 1,350 | 04.01 | 000000000000101 |  |  |  |  |
| 101 | 4.1.1 | PROGRAMA DE CAPACITACIÓN Y MANEJO AMBIENTAL | 175d | 2012-06-01 | 2012-11-23 |  | 10d |  | UTILES DE ESCRITORIO (VER DETALLE EN CUADRO 12.2.1) | 8h | 1,350 | 04.01.01 | 000000000000102 |  | 1350 | 1350 |  |

| ID | WBS | Task | Duration | Start | Finish | Predecessors | Total slack | Free slack | Resources | Work | Cost | Text1 | Text8 | Text2 | Text3 | Text4 | Text6 |
| --- | --- | --- | --- | --- | --- | --- | --- | --- | --- | --- | --- | --- | --- | --- | --- | --- | --- |
| 102 | 4.2 | **PROGRAMA DE MEDIDAS PREVENTIVAS Y CORRECTIVAS** | 176d | 2012-06-01 | 2012-11-24 |  | 9d |  |  | 23.95h | 10,516.04 | 04.02 | 000000000000103 |  |  |  |  |
| 103 | 4.2.1 | APERTURA DME | 1d | 2012-06-08 | 2012-06-09 | 55 | 169d | 1d | CAPATAZ [6%]; OFICIAL [12%]; PEON [120%]; TRACTOR DE ORUGAS DE 140 -160 HP [30%] | 13.44h | 722.68 | 04.02.01 | 000000000000104 | 0.15 | 4817.87 | 722.68 | 0.25 |
| 104 | 4.2.2 | ALMACENAMIENTO DE LUBRICANTES, COMBUSTIBLES, GRASAS Y OTROS | 175d | 2012-06-01 | 2012-11-23 | 3SS | 9d | 0d | CAPATAZ [10%]; OFICIAL [0.1%]; PEON [20%]; CAMION VOLQUETE 15 m3 [1.1%]; CARGADOR SOBRE LLANTAS 125-155 HP 3 yd3 [0.1%]; ESTACA DE MADERA [600%]; CINTA DE SEGURIDAD [50%]; CILINDROS METÁLICOS EN BUEN ESTADO Y CON TAPA (55Gal) [500%] | 2.51h | 397.36 | 04.02.02 | 000000000000105 |  | 397.36 | 397.36 |  |
| 105 | 4.2.3 | DISPOSICION FINAL DE LUBRICANTES, COMBUSTIBLES, GRASAS Y OTROS | 1d | 2012-11-23 | 2012-11-24 | 104 | 9d |  | ELIMINACIÓN DE LUBRICANTES GRASAS COMBUSTIBLES Y OTROS | 8h | 9,396 | 04.02.03 | 000000000000106 |  | 9396 | 9396 |  |
| 106 | 4.3 | **PROGRAMA DE SEGUIMIENTO Y MONITOREO AMBIENTAL** | 176d | 2012-06-01 | 2012-11-24 |  | 9d |  |  | 24h | 5,977.8 | 04.03 | 000000000000107 |  |  |  |  |
| 107 | 4.3.1 | MON ITOREO DE LA CALIDAD DEL AGUA | 100d | 2012-06-01 | 2012-11-21 |  | 9d | 0d | MONITOREO DE LA CALIDAD DEL AGUA (VER DETALLE EN CUADRO 12.2.3. a) [1%] | 8h | 1,630.8 | 04.03.01 | 000000000000108 |  | 1630.8 | 1630.8 |  |
| 108 | 4.3.2 | MON ITOREO DE LA CALIDAD DEL AIRE | 99d | 2012-06-01 | 2012-11-19 | 107SS | 9d | 0d | MONITOREO DE LA CALIDAD DEL AIRE (VER DETALLE EN CUADRO 12.2.3. b) [1%] | 8h | 3,591 | 04.03.02 | 000000000000109 |  | 3591 | 3591 |  |
| 109 | 4.3.3 | MON ITOREO DEL RUIDO | 98d | 2012-06-01 | 2012-11-24 | 108SS | 9d |  | MONITOREO DEL RUIDO (VER DETALLE EN CUADRO 12.2.3. c) [1%] | 8h | 756 | 04.03.03 | 000000000000110 |  | 756 | 756 |  |
| 110 | 4.4 | **PROGRAMA DE CONTINGENCIAS** | 1d | 2012-06-01 | 2012-06-02 |  | 153d |  |  | 32h | 42,044 | 04.04 | 000000000000111 |  |  |  |  |
| 111 | 4.4.1 | EQUIPO DE PRIMEROS AUXILIOS | 1d | 2012-06-01 | 2012-06-02 | 3SS | 153d | 0d | EQUIPO DE PRIMEROS AUXILIOS (VER DETALLE EN CUADRO 12.2.4 a) | 8h | 2,340 | 04.04.01 | 000000000000112 |  | 2340 | 2340 |  |
| 112 | 4.4.2 | IMPLEMENTOS DE SEGURIDAD | 1d | 2012-06-01 | 2012-06-02 | 111SS | 153d | 0d | IMPLEMENTOS DE SEGURIDAD (VER DETALLE EN CUADRO 12.2.4 b) | 8h | 32,644 | 04.04.02 | 000000000000113 |  | 32644 | 32644 |  |
| 113 | 4.4.3 | EQUIPOS CONTRA INCENDIOS | 1d | 2012-06-01 | 2012-06-02 | 112SS | 153d | 0d | EQUIPOS CONTRA INCENDIOS (VER DETALLE EN CUADRO 12.2.4 c) | 8h | 2,850 | 04.04.03 | 000000000000114 |  | 2850 | 2850 |  |
| 114 | 4.4.4 | EQUIPOS CONTRA DERRAMES DE SUSTANCIAS TÓXICAS | 1d | 2012-06-01 | 2012-06-02 | 113SS | 153d | 0d | EQUIPOS CONTRA DERRAMES DE SUSTANCIAS TÓXICAS (VER DETALLE EN CUADRO 12.2.4 d) | 8h | 4,210 | 04.04.04 | 000000000000115 |  | 4210 | 4210 |  |
| 115 | 4.5 | **PROGRAMA DE SEÑALIZACIÓN AMBIENTAL** | 1d | 2012-07-02 | 2012-07-03 |  | 153d |  |  | 71.21h | 2,959.8 | 04.05 | 000000000000116 |  |  |  |  |
| 116 | 4.5.1 | SEÑALIZACION TEMPORAL | 1d | 2012-07-02 | 2012-07-03 | 114FS+30d | 153d | 0d | SEÑALES AMBIENTALES TEMPORALES [800%] | 64h | 1,440 | 04.05.01 | 000000000000132 |  | 180 | 1440 | 140 |
| 117 | 4.5.2 | SEÑALES AMBIENTALES (SIMILAR A LA SEÑAL INFORMATIVA) | 1d | 2012-07-02 | 2012-07-03 | 116SS | 153d |  | PINTURA ANTICORROSIVA [16.9%]; TINTA SERIGRAFICA NEGRA O ROJA [42.2%]; PINTURA ESMALTE SINTETICO [16.9%]; CAPATAZ [5.6%]; OPERARIO [42.2%]; OFICIAL [42.2%]; SOLDADURA AWS E6011 [13.5%]; ANGULO DE ACERO 1" X 1" X 3/16" [777.4%]; PLATINA DE ACERO 2" X 1/8" [486.7%]; TUBO DE FIERRO GALVANIZADO D= 2" esp=2.5mm [1761%]; FIBRA DE VIDRIO DE 4 mm ACABADO [170.7%]; LAMINA REFLECTIVA ALTA INTENSIDAD [1828.6%]; PERNOS 1/4" X 3" [804.4%]; PLANCHA METALICA ASTM A36 e=1/4" 0.125 m x 0.125 m. [402.2%]; PERNO AUTOEXPANSIVOS TIPO CUÑA 3/8" X 5" [1352%] | 7.21h | 1,519.8 | 04.05.02 | 000000000000122 | 1.69 | 899.29 | 1519.8 |  |
| 118 | 4.6 | **PROGRAMA DE ABANDONO DE OBRAS** | 172d | 2012-06-13 | 2012-12-02 |  | 1d |  |  | 813.65h | 32,734.67 | 04.06 | 000000000000123 |  |  |  |  |
| 119 | 4.6.1 | REHABILITACIÓN AMBIENTAL DE CAMPAMENTO Y PATIO DE MÁQUINAS | 2d | 2012-11-28 | 2012-11-30 | 3FS-5d, 39FS-2d, 64FS-3d, 98FS-3d, 123FS-3d | 3d |  | PEON [545.6%]; CAMION CISTERNA 4 X 2 (AGUA) 122 HP 2 000 gl [91.2%]; TRACTOR DE ORUGAS DE 140 -160 HP [75.7%] | 114h | 5,936.35 | 04.06.01 | 000000000000124 | 6057.5 | 0.98 | 5936.35 | 4000 |
| 120 | 4.6.2 | REHABILITACIÓN AMBIENTAL DE PASE PROVISIONAL | 1d | 2012-12-01 | 2012-12-02 | 40FS+3d | 0d |  | CAPATAZ [35.5%]; OFICIAL [69.3%]; PEON [468.8%]; CAMION CISTERNA 4 X 2 (AGUA) 122 HP 2 000 gl [42.8%]; CAMION VOLQUETE 15 m3 [114.1%]; TRACTOR DE ORUGAS DE 140 -160 HP [35.5%]; CARGADOR SOBRE LLANTAS 125-155 HP 3 yd3 [69.3%]; RETROEXCAVADORA SOBRE ORUGAS 115-165 HP -1.4 yd3 (1.10 m3) [35.5%] | 69.67h | 5,637.96 | 04.06.02 | 000000000000125 | 1420.14 | 3.97 | 5637.96 | 2000 |
| 121 | 4.6.3 | ACOMODO DE MATERIAL EXCEDENTE EN DME | 5d | 2012-06-13 | 2012-06-18 | 90 | 168d | 167d | CAPATAZ [9.1%]; OFICIAL [91.1%]; PEON [182.3%]; TRACTOR DE ORUGAS DE 140 -160 HP [18.2%] | 168.41h | 4,513.34 | 04.06.03 | 000000000000126 | 1594.82 | 2.83 | 4513.34 | 250 |
| 122 | 4.6.4 | REHABILITACIÓN AMBIENTAL DE CANTERAS EN TIERRA | 1d | 2012-11-27 | 2012-11-28 | 60, 65, 40FF | 2d | 0d | CAPATAZ [12.9%]; PEON [291.8%]; CAMION CISTERNA 4 X 2 (AGUA) 122 HP 2 000 gl [49.7%]; TRACTOR DE ORUGAS DE 140 -160 HP [61.8%] | 66.59h | 4,039.56 | 04.06.04 | 000000000000127 | 4122 | 0.98 | 4039.56 | 3400 |
| 123 | 4.6.5 | REHABILITACIÓN AMBIENTAL DE CANTERAS EN LECHO DE RIO | 3d | 2012-11-28 | 2012-12-01 | 122 | 2d | 0d | CAPATAZ [20.6%]; PEON [466%]; CAMION CISTERNA 4 X 2 (AGUA) 122 HP 2 000 gl [79.3%]; TRACTOR DE ORUGAS DE 140 -160 HP [98.7%] | 159.49h | 9,674.56 | 04.06.05 | 000000000000128 | 9872 | 0.98 | 9674.56 | 3400 |
| 124 | 4.6.6 | REVEGETACION | 3d | 2012-11-29 | 2012-12-02 | 120FF, 121FS-3d | 1d |  | CAPATAZ [8.8%]; OFICIAL [88.3%]; PEON [883.7%]; CAMION CISTERNA 4 X 2 (AGUA) 122 HP 2 000 gl [0.3%]; PLANTAS NATIVAS [159%] | 235.48h | 2,932.9 | 04.06.06 | 000000000000129 | 0.53 | 5533.77 | 2932.9 | 0.2 |
| 125 | 4.7 | **PROGRAMA DE ASUNTOS SOCIALES** | 175d | 2012-06-01 | 2012-11-23 |  | 9d |  |  | 8h | 2,000 | 04.07 | 000000000000130 |  |  |  |  |
| 126 | 4.7.1 | MECANISMOS DE COMUNICACIÓN E INFORMACIÓN ENTRE POBLADORES Y EMPRESA | 175d | 2012-06-01 | 2012-11-23 |  | 9d |  | MECANISMOS DE COMUNICACIÓN E INFORMACIÓN ENTRE POBLADORES Y EMPRES | 8h | 2,000 | 04.07.01 | 000000000000131 |  | 2000 | 2000 |  |

| ID | WBS | Task | Duration | Start | Finish | Predecessors | Total slack |
| --- | --- | --- | --- | --- | --- | --- | --- |
| 127 | 4.8 | **ENTREGA DE OBRA** | 1d? | 2012-12-02 | 2012-12-03 |  | 0d |
| 128 | 4.8.1 | ENTREGA DE OBRA | 1d? | 2012-12-02 | 2012-12-03 | 17, 33, 43, 45, 46, 50, 51, 79, 120, 126, 96, 80, 82, 91, 12, 13, 14, 15 | 0d |
